# Programación Evitamiento Trujillo

Schedule from MS Project, 2011-08-01 to 2011-12-04, scheduled back from the finish, A marks actual dates.
GMI SA

## Calendars

- Estándar: Mon-Sun 09:00-13:00, 15:00-19:00.

## Resources

| Resource |
| --- |
| 12 |
| 01.01 |
| 01 |
| 01.02 |
| 01.03 |
| 01.04 |
| 02 |
| 02.01 |
| 02.01.01 |
| 02.01.03 |
| 02.01.02 |
| 02.01.04 |
| 02.01.05 |
| 02.01.06 |
| 02.01.07 |
| 02.01.08 |
| 02.01.09 |
| 02.01.10 |
| 02.01.11 |
| 02.02 |
| 02.02.01 |
| 02.02.02 |
| 02.02.03 |
| 02.02.04 |
| 02.02.05 |
| 02.02.07 |
| 02.02.06 |
| 02.02.08 |
| 02.02.09 |
| 03 |
| 03.1 |
| 03.01 |
| 03.01.01 |
| 03.01.02 |
| 03.01.03 |
| 03.01.04 |
| 03.01.05 |
| 03.01.06 |
| 03.01.07 |
| 03.02 |
| 03.02.01 |
| 03.02.02 |
| 03.02.03 |
| 03.02.04 |
| 03.02.05 |
| 03.02.06 |
| 03.02.07 |
| 03.02.08 |
| 03.02.09 |
| 03.02.10 |
| 03.02.11 |
| 03.02.12 |
| 03.02.13 |
| 03.02.14 |
| 03.02.15 |
| 03.02.16 |
| 03.02.17 |
| 03.02.18 |
| 03.02.19 |
| 03.02.20 |
| / |
| 03.02.21 |
| 03.02.22 |
| 04 |
| 04.01 |
| 04.02 |
| 04.03 |
| 04.04 |
| 04.05 |
| 04.06 |
| 05 |
| 05.01 |
| 05.02 |
| 05.03 |
| 05.04 |
| 05.05 |
| 05.06 |
| 05.07 |
| 05.08 |
| 05.09 |
| 05.010 |
| 05.10 |
| 05.11 |
| 05.12 |
| 05.13 |
| 05.14 |
| 05.15 |
| 05.16 |
| 05.17 |
| 05.18 |
| 05.19 |
| 05.20 |
| 05.21 |
| 05.22 |
| 05.23 |
| 05.24 |
| 05.25 |
| 05.26 |
| 05.27 |
| 06 |
| 06.01 |
| 06.02 |
| 06.03 |
| 06.04 |
| 06.05 |
| 06.06 |
| 06.07 |
| 04.07 |
| 04.08 |
| 05.28 |
| 02.01.12 |
| 05.29 |

## Schedule

| ID | WBS | Task | Type | Duration | Start | Finish | Predecessors | Complete | Remaining | Total slack | Free slack | Constraint | Resources | Work | Actual work | Text1 |
| --- | --- | --- | --- | --- | --- | --- | --- | --- | --- | --- | --- | --- | --- | --- | --- | --- |
| 1 | 1 | **EJECUCIÓN DE OBRA** |  | 126d? | 2011-08-01 A | 2011-12-04 |  |  | 125.93d? | 0d |  | as late as possible |  | 18408h | 10.32h | 120 días |
| 2 | 1.1 | INICIO DE OBRA | milestone | 0d | 2011-08-01 | 2011-08-04 |  |  |  | 0d |  | start no later than 2011-08-01 |  |  |  | 0 días |
| 3 | 1.2 | **OBRAS PRELIMINARES** |  | 33d | 2011-08-01 | 2011-09-02 |  |  |  | 0d |  | as late as possible | 01 | 824h |  | 117 días |
| 4 | 1.2.1 | MOVILIZACION DE MAQUINARIAS HERRAMIENTAS PARA LA OBRA |  | 2d | 2011-08-04 | 2011-08-05 | 2 |  |  | 0d |  | finish no later than 2011-08-05 | 01.01 | 16h |  | 2 días |
| 5 | 1.2.2 | TOPOGRAFIA Y REFERENCIACION |  | 30d | 2011-08-04 | 2011-09-02 | 2 |  |  | 0d |  | start no earlier than 2011-07-08 | 01.02 | 240h |  | 30 días |
| 6 | 1.2.3 | MANTENIMIENTO DE TRANSITO Y SEGURIDAD VIAL |  | 30d | 2011-08-04 | 2011-09-02 | 2 |  |  | 0d |  | start no earlier than 2011-07-10 | 01.03 | 240h |  | 30 días |
| 7 | 1.2.4 | ACCESOS A CANTERAS, DME, PLANTAS Y FUENTES DE AGUA |  | 8d | 2011-08-01 | 2011-08-08 |  |  |  | 0d |  | start no earlier than 2011-07-08 | 01.04 | 64h |  | 8 días |
| 8 | 1.3 | **PAVIMENTOS** |  | 95d | 2011-08-09 A | 2011-11-11 | 4 |  | 94.87d | 10d | 0d | as late as possible | 02 | 7832h | 10.32h | 115 días |
| 9 | 1.3.1 | **CALZADA** |  | 85d | 2011-08-09 A | 2011-11-01 |  |  | 84.8d | 0d |  | as late as possible | 02.01 | 4040h | 9.39h | 115 días |
| 10 | 1.3.1.1 | FRESADO DE CARPETA ASFÁLTICA E=2.5 CM |  | 9d | 2011-08-09 | 2011-09-27 | 7 |  |  | 65d | 68d |  | 02.01.01 | 72h |  | 7 días |
| 11 | 1.3.1.2 | BACHEO SUPERFICIAL |  | 25d | 2011-08-19 | 2011-09-12 |  |  |  | 13d | 0d | start no earlier than 2011-07-16 | 02.01.05 | 200h |  | 25 días |
| 12 | 1.3.1.3 | RIEGO DE LIGA |  | 55d | 2011-08-24 | 2011-10-17 |  |  |  | 18d | 0d | start no earlier than 2011-07-16 | 02.01.06 | 440h |  | 55 días |
| 13 | 1.3.1.4 | EMULSIÓN ASFÁLTICA DE ROTURA LENTA |  | 55d | 2011-08-24 | 2011-10-17 |  |  |  | 18d | 0d | start no earlier than 2011-07-16 | 02.01.07 | 440h |  | 55 días |
| 14 | 1.3.1.5 | RECAPADO ASFÁLTICO |  | 66d | 2011-08-21 | 2011-10-25 | 7 |  |  | 12d | 0d | start no earlier than 2011-07-25 | 02.01.08 | 528h |  | 55 días |
| 15 | 1.3.1.6 | CEMENTO ASFALTICO PEN 60 - 70 |  | 55d | 2011-09-08 A | 2011-11-01 |  | 2% | 54d | 0d |  | start no earlier than 2011-07-25 | 02.01.09 | 440h | 8h | 55 días |
| 16 | 1.3.1.7 | FILLER |  | 55d | 2011-09-07 | 2011-10-31 |  |  |  | 32d | 0d | finish no later than 2011-10-31 | 02.01.10 | 440h |  | 55 días |
| 17 | 1.3.1.8 | ADITIVO MEJORADOR DE ADHERENCIA |  | 55d | 2011-09-07 | 2011-10-31 |  |  |  | 32d | 0d | finish no later than 2011-10-31 | 02.01.11 | 440h |  | 55 días |
| 18 | 1.3.1.9 | SLURRY SEAL |  | 55d | 2011-09-07 | 2011-10-31 |  |  |  | 32d | 0d | finish no later than 2011-10-31 | 02.01.12 | 440h |  | 55 días |
| 19 | 1.3.2 | **BERMAS** |  | 87d | 2011-08-17 | 2011-11-11 |  |  |  | 11d | 0d | as late as possible | 02.02 | 3112h |  | 107 días |
| 20 | 1.3.2.1 | ESCARIFICADO DE BERMAS |  | 50d | 2011-08-17 | 2011-10-05 |  |  |  | 0d |  | start no earlier than 2011-08-17 | 02.02.01 | 400h |  | 50 días |
| 21 | 1.3.2.2 | RECONFORMACIÓN DE BERMAS CON ADICIÓN DE RAP |  | 50d | 2011-09-23 | 2011-11-11 |  |  |  | 29d | 0d | start no earlier than 2011-08-25 | 02.02.02 | 400h |  | 50 días |
| 22 | 1.3.2.3 | IMPRIMACIÓN ASFÁLTICA EN BERMAS |  | 50d | 2011-09-23 | 2011-11-11 |  |  |  | 29d | 0d | start no earlier than 2011-08-25 | 02.02.03 | 400h |  | 50 días |
| 23 | 1.3.2.4 | ASFALTO DILUIDO MC-30 |  | 50d | 2011-09-23 | 2011-11-11 |  |  |  | 29d | 0d | start no earlier than 2011-08-25 | 02.02.04 | 400h |  | 50 días |
| 24 | 1.3.2.5 | TRATAMIENTO SUPERFICIAL BICAPA |  | 52d | 2011-09-11 | 2011-11-10 |  |  |  | 36d | 0d | finish no later than 2011-11-10 | 02.02.05 | 416h |  | 50 días |
| 25 | 1.3.2.6 | EMULSIÓN ASFÁLTICA DE ROTURA RAPIDA |  | 50d | 2011-09-23 | 2011-11-11 |  |  |  | 27d | 0d | start no earlier than 2011-08-27 | 02.02.06 | 400h |  | 50 días |

| ID | WBS | Task | Duration | Start | Finish | Predecessors | Total slack | Free slack | Constraint | Resources | Work | Text1 |
| --- | --- | --- | --- | --- | --- | --- | --- | --- | --- | --- | --- | --- |
| 26 | 1.4 | **OBRAS DE ARTE Y DRENAJE** | 20d | 2011-08-01 | 2011-08-20 |  | 0d |  | as late as possible | 03 | 1184h | 95 días |
| 27 | 1.4.1 | **OBRAS DE ARTE MENORES** | 20d | 2011-08-01 | 2011-08-20 |  | 0d |  | as late as possible | 03.01 | 1024h | 89 días |
| 28 | 1.4.1.1 | ROCE | 20d | 2011-08-01 | 2011-08-20 |  | 103d | 106d |  | 03.01.01 | 160h | 20 días |
| 29 | 1.4.1.2 | LIMPIEZA DE ALCANTARILLAS Y PONTONES | 20d | 2011-08-01 | 2011-08-20 |  | 103d | 106d |  | 03.01.02 | 160h | 20 días |
| 30 | 1.4.1.3 | DESCOLMATACIÓN DE ALCANTARILLAS Y PONTONES | 20d | 2011-08-01 | 2011-08-20 |  | 103d | 106d |  | 03.01.03 | 160h | 20 días |
| 31 | 1.4.1.4 | REPARACION DE CABEZALES Y LOSA DE ALCANTARILLA | 16d | 2011-08-01 | 2011-08-16 |  | 107d | 110d |  | 03.01.04 | 128h | 16 días |
| 32 | 1.4.1.5 | REPARACION SUPERFICAL DE CONCRETO | 16d | 2011-08-02 | 2011-08-17 |  | 1d | 0d | finish no later than 2011-08-17 | 03.01.05 | 128h | 16 días |
| 33 | 1.4.1.6 | PINTURA ASFALTICA | 16d | 2011-08-02 | 2011-08-17 |  | 1d | 0d | finish no later than 2011-08-17 | 03.01.06 | 128h | 16 días |
| 34 | 1.5 | **TRANSPORTE** | 100d | 2011-08-07 | 2011-11-14 |  | 6d | 0d | as late as possible | 04 | 6080h | 117 días |
| 35 | 1.5.1 | TRANSPORTE DE MATERIAL GRANULAR D<= 1 KM | 90d | 2011-08-17 | 2011-11-14 |  | 16d | 0d | start no earlier than 2011-07-16 | 04.01 | 720h | 90 días |
| 36 | 1.5.2 | TRANSPORTE DE MATERIAL GRANULAR D>1 KM | 90d | 2011-08-17 | 2011-11-14 |  | 16d | 0d | start no earlier than 2011-07-16 | 04.02 | 720h | 90 días |
| 37 | 1.5.3 | TRANSPORTE DE MATERIAL EXCEDENTE D<= 1 KM | 100d | 2011-08-07 | 2011-11-14 |  | 6d | 0d | start no earlier than 2011-08-01 | 04.03 | 800h | 100 días |
| 38 | 1.5.4 | TRANSPORTE DE MATERIAL EXCEDENTE D> 1 KM | 100d | 2011-08-07 | 2011-11-14 |  | 6d | 0d | start no earlier than 2011-08-01 | 04.04 | 800h | 100 días |
| 39 | 1.5.5 | TRANSPORTE DE MEZCLA ASFALTICA D<= 1 KM | 90d | 2011-08-17 | 2011-11-14 |  | 16d | 0d | start no earlier than 2011-07-16 | 04.05 | 720h | 90 días |
| 40 | 1.5.6 | TRANSPORTE DE MEZCLA ASFALTICA D<= 1 KM | 90d | 2011-08-17 | 2011-11-14 |  | 16d | 0d | start no earlier than 2011-07-16 | 04.06 | 720h | 90 días |
| 41 | 1.5.7 | TRANSPORTE DE MATERIAL RAD D> 1 KM | 50d | 2011-08-27 | 2011-10-15 |  | 26d | 0d | start no earlier than 2011-07-16 | 04.07 | 400h | 50 días |
| 42 | 1.5.8 | TRANSPORTE DE MATERIAL RAD D> 1 KM | 50d | 2011-08-27 | 2011-10-15 |  | 26d | 0d | start no earlier than 2011-07-16 | 04.08 | 400h | 50 días |
| 43 | 1.6 | **SEÑALIZACION Y SEGURIDAD VIAL** | 60d? | 2011-10-06 | 2011-12-04 |  | 0d |  | as late as possible | 05 | 992h | 60 días |
| 44 | 1.6.1 | SEÑAL PREVENTIVA DE 0.75 M X 0.75 M | 4d | 2011-10-06 | 2011-10-09 | 20 | 28d |  |  | 05.01 | 32h | 4 días |
| 45 | 1.6.2 | REEMPLAZO DE SEÑAL PREVENTIVA DE 0.75 X 0.75 M. | 2d | 2011-10-26 | 2011-10-27 | 20, 14 | -7d | 0d | start no earlier than 2011-10-26 | 05.02 | 16h | 2 días |
| 46 | 1.6.3 | MANTENIMIENTO DE SEÑAL PREVENTIVA | 3d | 2011-10-28 | 2011-10-30 | 45 | 0d |  | start no earlier than 2011-03-07 | 05.03 | 24h | 3 días |
| 47 | 1.6.4 | REEMPLAZO DE SEÑAL REGLAMENTARIA DE 0.80 X 1.20 M. | 2d | 2011-10-31 | 2011-11-01 | 46 | 0d |  | start no earlier than 2011-03-07 | 05.04 | 16h | 2 días |
| 48 | 1.6.5 | MANTENIMIENTO DE SEÑAL REGLAMENTARIA | 2d | 2011-11-02 | 2011-11-03 | 47 | 0d |  | start no earlier than 2011-03-07 | 05.05 | 16h | 2 días |
| 49 | 1.6.6 | SEÑAL INFORMATIVA | 3d | 2011-11-04 | 2011-11-06 | 48 | 0d |  | start no earlier than 2011-03-07 | 05.06 | 24h | 3 días |
| 50 | 1.6.7 | REEMPLAZO DE SEÑAL INFORMATIVA | 7d | 2011-10-31 | 2011-11-06 | 49 | -7d | 0d |  | 05.07 | 56h | 7 días |
| 51 | 1.6.8 | MANTENIMIENTO DE SEÑAL INFORMATIVA | 2d | 2011-11-14 | 2011-11-15 | 50 | 0d |  | start no earlier than 2011-03-07 | 05.08 | 16h | 2 días |
| 52 | 1.6.9 | REEMPLAZO DE POSTE DE SOPORTE DE SEÑAL | 2d | 2011-11-16 | 2011-11-17 | 51 | 0d |  | start no earlier than 2011-03-07 | 05.09 | 16h | 2 días |
| 53 | 1.6.10 | MANTENIMIENTO DE POSTE DE SOPORTE DE SEÑAL | 4d | 2011-11-11 | 2011-11-14 | 52 | -7d | 0d |  | 05.10 | 32h | 4 días |
| 54 | 1.6.11 | ESTRUCTURAS DE SOPORTE DE SEÑALES | 2d | 2011-11-22 | 2011-11-23 | 53 | 0d |  | start no earlier than 2011-03-07 | 05.11 | 16h | 2 días |
| 55 | 1.6.12 | REEMPLAZO DE ESTRUCTURAS DE SOPORTE DE SEÑALES | 2d | 2011-11-24 | 2011-11-25 | 54 | 6d | 9d |  | 05.12 | 16h | 2 días |
| 56 | 1.6.13 | MANTENIMIENTO DE ESTRUCTURAS DE SOPORTE DE SEÑAL | 2d | 2011-11-30 | 2011-12-01 | 52 | 12d | 0d | start no earlier than 2011-11-10 | 05.13 | 16h | 2 días |
| 57 | 1.6.14 | MANTENIMIENTO DE POSTES DELINEADORES | 1d | 2011-11-11 | 2011-11-11 |  | -1d | 0d | start no earlier than 2011-11-11 | 05.16 | 8h | 1 día |
| 58 | 1.6.15 | TACHAS RETROREFLECTIVAS | 4d | 2011-11-11 | 2011-11-14 | 57 | -1d | 0d | start no earlier than 2011-03-07 | 05.17 | 32h | 4 días |
| 59 | 1.6.16 | MARCAS EN EL PAVIMENTO | 7d | 2011-11-25 | 2011-12-01 |  | 15d | 0d | finish no earlier than 2011-11-16 | 05.18 | 56h | 7 días |
| 60 | 1.6.17 | MANTENIMIENTO DE GUARDAVIAS | 3d | 2011-11-15 | 2011-11-17 | 53, 58 | -7d | 0d | start no earlier than 2011-11-15 | 05.19 | 24h | 3 días |
| 61 | 1.6.18 | POSTE KILOMETRICOS | 3d | 2011-11-28 | 2011-11-30 |  | -3d | 0d | start no earlier than 2011-11-28 | 05.25 | 24h | 3 días |
| 62 | 1.6.19 | MANTENIMIENTO DE POSTE KILOMETRICO | 4d | 2011-11-28 | 2011-12-01 | 61 | -3d | 0d |  | 05.26 | 32h | 4 días |
| 63 | 1.6.20 | REDUCTORES DE VELOCIDAD | 2d | 2011-12-01 | 2011-12-02 |  | 0d |  | start no earlier than 2011-12-01 | 05.27 | 16h | 2 días |
| 64 | 1.6.21 | POSTES DELINEADORES | 2d | 2011-12-01 | 2011-12-02 | 65 | 0d |  | start no earlier than 2011-12-01 | 05.28 | 16h | 2 días |
| 65 | 1.6.22 | POSTES DE SOPORTE DE SEÑALES | 1d? | 2011-10-23 | 2011-10-23 |  | 83d | 0d | finish no later than 2011-10-23 | 05.29 | 8h | 4 días |

| ID | WBS | Task | Type | Duration | Start | Finish | Predecessors | Total slack | Free slack | Constraint | Resources | Work | Text1 |
| --- | --- | --- | --- | --- | --- | --- | --- | --- | --- | --- | --- | --- | --- |
| 66 | 1.7 | **PROTECCION AMBIENTAL** |  | 123d | 2011-08-01 | 2011-12-01 |  | 0d |  | as late as possible | 06 | 1496h | 45 días |
| 67 | 1.7.1 | ACONDICIONAMIENTO DE DEPOSITO DE MATERIAL EXCEDENTE |  | 2d | 2011-11-29 | 2011-11-30 |  | 120d | 0d | finish no later than 2011-11-30 | 06.01 | 16h | 15 días |
| 68 | 1.7.2 | READECUACION AMBIENTAL DE CANTERAS, PLANTAS DE CHANCADO Y ASFALTO |  | 7d | 2011-11-25 | 2011-12-01 |  | 4d | 0d | start no earlier than 2011-11-21 | 06.02 | 56h | 7 días |
| 69 | 1.7.3 | READECUACION AMBIENTAL DE CAMPAMENTOS, ALMACENES Y PATIOS DE MAQUINAS |  | 3d | 2011-08-01 | 2011-08-03 |  | 120d | 123d |  | 06.03 | 24h | 3 días |
| 70 | 1.7.4 | SEÑALIZACION AMBIENTAL |  | 2d | 2011-08-01 | 2011-08-02 |  | 0d |  | finish no later than 2011-08-02 | 06.04 | 16h | 2 días |
| 71 | 1.7.5 | MONITOREO AIRE RUIDO |  | 5d | 2011-11-27 | 2011-12-01 |  | 37d | 0d | start no earlier than 2011-10-21 | 06.05 | 40h | 5 días |
| 72 | 1.7.6 | CAPACITACIÓN AMBIENTAL |  | 45d | 2011-08-01 | 2011-09-14 |  | 0d |  | finish no later than 2011-09-14 | 06.07 | 360h | 45 días |
| 73 | 1.8 | FIN DE OBRA | milestone | 0d | 2011-12-02 | 2011-12-02 | 72, 71, 69, 70, 59, 62, 55, 5FS+90d, 6FS+90d, 10, 11FS+80d, 12FS+45d, 21FS+20d, 22FS+20d, 23FS+20d, 24FS+20d, 28, 29, 30, 31, 35FS+17d, 36FS+17d, 37FS+17d, 39FS+17d, 42FS+47d, 41FS+47d, 15FS+30d, 16FS+30d, 17FS+30d, 40FS+17d, 68, 18FS+30d, 13FS+45d, 14FS+30d, 25FS+20d, 32, 33, 38FS+17d, 67, 56 | -3d | 0d | start no earlier than 2011-12-02 |  |  | 0 días |
